# PROYECTO 2 - PAQUETE 5 RIO CAÑETE

Schedule from Primavera P6, 2024-03-15 to 2024-12-30, data date 2024-03-15.

## Calendars

- CALENDARIO - CONST. CIVIL: Mon-Sat 08:00-12:00, 13:00-17:00; Sun off. Exceptions (off unless hours are given): 2024-05-01, 2024-06-07, 2024-06-29, 2024-07-29, 2024-08-06, 2024-08-30, 2024-10-08, 2024-11-01, 2024-12-09, 2024-12-25.

## Schedule

| ID | WBS | Activity | Type | Duration | Start | Finish | Predecessors | Total float | Free float |
| --- | --- | --- | --- | --- | --- | --- | --- | --- | --- |
|  | 1 | **HITOS** |  |  | 2024-03-15 | 2024-12-30 |  |  |  |
|  | 1 | **Hitos del Proyecto** |  |  | 2024-03-15 | 2024-12-30 |  |  |  |
| A1000 |  | Hito Inicio de Proyecto | milestone | 0d | 2024-03-15 | 2024-03-15 |  | 0d |  |
| A1010 |  | Hito de Fin de Proyecto | milestone | 0d | 2024-12-30 | 2024-12-30 | A1170 FF | 0d |  |
|  | 2 | **Hitos de Construcción** |  |  | 2024-05-02 | 2024-12-23 |  |  |  |
| A1020 |  | Hito Inicio de Construcción | milestone | 0d | 2024-05-02 | 2024-05-02 | A1000 SS+40d | 0d |  |
| A1025 |  | hito Inicio Construcción ETAPA I | milestone | 0d | 2024-05-02 | 2024-05-02 | A1020 SS | 0d |  |
| A1030 |  | Hito Inicio Paso Superior Tipo Marco - ETAPA I | milestone | 0d | 2024-06-24 | 2024-06-24 | A1750 | 64d | 0d |
| A1040 |  | Hito Inicio Interferencias - ETAPA I | milestone | 0d | 2024-06-24 | 2024-06-24 | A1740 | 20d | 0d |
| A1090 |  | Hito Inicio Etapa II | milestone | 0d | 2024-08-14 | 2024-08-14 | A1825 | 0d |  |
| A1060 |  | Hito Fin Paso Superior Tipo Marco - ETAPA I | milestone | 0d | 2024-09-23 | 2024-09-23 | A1985 FF | 80d |  |
| A4840 |  | Hito Inicio Paso Superior Tipo Marco - ETAPA II | milestone | 0d | 2024-10-01 | 2024-10-01 | A3750 | 70d | 0d |
| A4850 |  | Hito Inicio Interferencias - ETAPA II | milestone | 0d | 2024-10-01 | 2024-10-01 | A3740 | 19d | 0d |
| A1070 |  | Hito Fin Interferencias - ETAPA I | milestone | 0d | 2024-11-22 | 2024-11-22 | A2600 FF | 30d | 0d |
| A1080 |  | Hito Fin Etapa I | milestone | 0d | 2024-11-22 | 2024-11-22 | A1070 FF | 30d |  |
| A4880 |  | Hito Fin de Interferencias - ETAPA II | milestone | 0d | 2024-12-04 | 2024-12-04 | A4590 FF | 20d |  |
| A4870 |  | Hito Fin Paso Superior Tipo Marco - ETAPA II | milestone | 0d | 2024-12-14 | 2024-12-14 | A3985 FF | 12d |  |
| A4980 |  | Hito Fin ETAPA II | milestone | 0d | 2024-12-19 | 2024-12-19 | A5010 FF, A5030 FF, A1160 FF, A3900 FF, A5020 FF, A5040 FF | 8d |  |
| A5000 |  | Hito Fin de Construcción | milestone | 0d | 2024-12-23 | 2024-12-23 | A4970 FF | 5d |  |
|  | 2 | **TRABAJOS PRELIMINARES Y ACOMPAÑAMIENTO** |  |  | 2024-03-15 | 2024-12-30 |  |  |  |
|  | 1 | **Trabajos provisionales** |  |  | 2024-03-15 | 2024-12-30 |  |  |  |
| A1110 |  | Campamento Provisional de Obra |  | 40d | 2024-03-15 | 2024-04-30 | A1000 SS | 199d | 0d |
| A1120 |  | Movilización de maquinaria pesada |  | 25d | 2024-03-15 | 2024-04-12 | A1110 SS | 199d | 0d |
| A1150 |  | Limpieza manual de material vegetal y residuos |  | 30d | 2024-03-15 | 2024-04-18 | A1110 SS | 209d |  |
| A1140 |  | Habilitación de plataformas |  | 30d | 2024-03-27 | 2024-04-30 | A1120 SS+10d | 199d |  |
| A1130 |  | Mejoramiento y Habilitación de camino de acceso |  | 22d | 2024-04-05 | 2024-04-30 | A1120 SS+18d | 199d |  |
| A1160 |  | Mantenimiento de caminos de acceso | level of effort | 191d | 2024-05-02 | 2024-12-19 | A1025 SS | 8d | 0d |
| A1170 |  | Desmovilización de maquinaria pesada |  | 25d | 2024-11-29 | 2024-12-30 | A4960 FF+7d | 0d |  |

| ID | WBS | Activity | Type | Duration | Start | Finish | Predecessors | Total float | Free float |
| --- | --- | --- | --- | --- | --- | --- | --- | --- | --- |
|  | 2 | **Trabajos preliminares** |  |  | 2024-04-13 | 2024-12-19 |  |  |  |
| A5010 |  | Trazo y replanteo | level of effort | 206d | 2024-04-13 | 2024-12-19 | A1120 | 8d | 0d |
|  | 3 | **Señalización** |  |  | 2024-05-02 | 2024-12-19 |  |  |  |
| A5020 |  | Seguridad vial - Señalización Vertical y horizontal | level of effort | 191d | 2024-05-02 | 2024-12-19 | A1020 SS | 8d | 0d |
|  | 4 | **Transportes** |  |  | 2024-03-15 | 2024-12-19 |  |  |  |
| A5030 |  | Transportes de materiales de préstamos, excedentes, rocas, orgánicos | level of effort | 231d | 2024-03-15 | 2024-12-19 |  | 8d | 0d |
|  | 5 | **Calidad** |  |  | 2024-05-02 | 2024-12-19 |  |  |  |
| A5040 |  | Control de Calidad | level of effort | 191d | 2024-05-02 | 2024-12-19 | A1025 SS | 8d | 0d |
|  | 3 | **CONSTRUCCIÓN** |  |  | 2024-05-02 | 2024-12-23 |  |  |  |
|  | 1 | **ETAPA I - SAN JERÓNIMO Y CONDORAY** |  |  | 2024-05-02 | 2024-12-04 |  |  |  |
|  | 1 | **FRENTE 1 - DEMOLICIONES** |  |  | 2024-05-02 | 2024-07-09 |  |  |  |
| A1710 |  | Demolicion de Canales en Qdas. y Badenes |  | 47d | 2024-05-02 | 2024-06-26 | A1025 SS | 0d |  |
| A1720 |  | Demolicion de Pavimentos, veredas y cerco perimétrico |  | 10d | 2024-06-27 | 2024-07-09 | A1710 | 142d | 0d |
| A1725 |  | Eliminacion de material de demolicion |  | 5d | 2024-07-04 | 2024-07-09 | A1720 FF | 142d |  |
|  | 2 | **FRENTE 2 - MOVIMIENTO DE TIERRAS** |  |  | 2024-05-02 | 2024-08-15 |  |  |  |
| A1730 |  | Desbroce |  | 3d | 2024-05-02 | 2024-05-04 | A1710 SS | 0d |  |
| A1740 |  | Excavación de cimentación |  | 41d | 2024-05-06 | 2024-06-22 | A1730 | 0d |  |
| A1750 |  | Perfilado y conformación de Plataforma de fundación |  | 22d | 2024-05-28 | 2024-06-22 | A1740 FF | 0d |  |
| A1820 |  | Suministro de Roca |  | 24d | 2024-06-21 | 2024-07-19 | A1780 FF | 133d |  |
| A1760 |  | Conformación de material excedente en DME y DMO |  | 28d | 2024-06-24 | 2024-07-26 | A1740 | 127d |  |
| A1770 |  | Relleno con material granular (incluye extracción de material, zarandeo y combinación de material) |  | 2d | 2024-06-24 | 2024-06-25 | A1750 | 153d |  |
| A1780 |  | Relleno Estructural |  | 22d | 2024-06-24 | 2024-07-19 | A1750 | 0d |  |
| A1830 |  | Roca Recebada |  | 30d | 2024-06-26 | 2024-08-01 | A1780 SS+2d | 0d |  |
| A1825 |  | Colocación de Roca en Uña |  | 9d | 2024-08-02 | 2024-08-13 | A1830 | 0d |  |
| A1840 |  | Subbase granular |  | 2d | 2024-08-14 | 2024-08-15 | A1825 | 112d |  |

| ID | WBS | Activity | Duration | Start | Finish | Predecessors | Total float | Free float |
| --- | --- | --- | --- | --- | --- | --- | --- | --- |
|  | 3 | **FRENTE 3 - ESTRUCTURAS CANALIZADAS** |  | 2024-06-10 | 2024-09-23 |  |  |  |
|  | 1 | **F3 - OBRAS DE CONCRETO SIMPLE** |  | 2024-06-24 | 2024-09-16 |  |  |  |
| A1845 |  | ENCOFRADO Y DESENCOFRADO CARA OCULTA | 45d | 2024-06-24 | 2024-08-17 | A1750 | 86d | 0d |
| A1850 |  | CONCRETO CLASE F(F'C=100 KG/CM2) - SOLADOS | 3d | 2024-08-19 | 2024-08-21 | A1845 | 86d | 0d |
| A1860 |  | CONCRETO CLASE A (F'C=280 KG/CM2)- PREMEZCLADO-MUROS+30% PM / DMAX=4"/6" | 21d | 2024-08-22 | 2024-09-16 | A1850 | 86d |  |
|  | 2 | **F3 - OBRAS DE CONCRETO ARMADO** |  | 2024-06-10 | 2024-09-23 |  |  |  |
| A1870 |  | GEOCOMPUESTO DE DRENAJE | 8d | 2024-06-10 | 2024-06-18 | A1750 SS+10d | 80d | 0d |
| A1880 |  | ACERO FY=4200 KG/CM2, GRADO 60 | 74d | 2024-06-19 | 2024-09-17 | A1870 | 80d | 0d |
| A1890 |  | ENCOFRADO Y DESENCOFRADO CARA VISTA, OCULTA Y TUBOS PVC - D=4"/6" | 33d | 2024-08-09 | 2024-09-17 | A1880 FF | 80d | 0d |
| A1900 |  | CONCRETO CLASE A (F'C=280 KG/CM2)- PREMEZCLADO-MUROS+30% PM DMAX=6" | 5d | 2024-09-18 | 2024-09-23 | A1890 | 80d |  |
|  | 4 | **FRENTE 4 - PASO SUPERIOR TIPO MARCO** |  | 2024-06-24 | 2024-09-23 |  |  |  |
|  | 1 | **F4 - OBRAS DE CONCRETO SIMPLE** |  | 2024-06-24 | 2024-06-28 |  |  |  |
| A1920 |  | ENCOFRADO Y DESENCOFRADO EN ESTRUCTURAS | 3d | 2024-06-24 | 2024-06-26 | A1030 SS | 150d | 0d |
| A1910 |  | CONCRETO CLASE F(F'C=100 KG/CM2) - SOLADOS | 2d | 2024-06-27 | 2024-06-28 | A1920 | 150d |  |
|  | 2 | **F4 - OBRAS DE CONCRETO ARMADO** |  | 2024-06-24 | 2024-09-16 |  |  |  |
| A1930 |  | GEOCOMPUESTO DE DRENAJE | 2d | 2024-06-24 | 2024-06-25 | A1030 SS | 64d | 0d |
| A1940 |  | ACERO FY=4200 KG/CM2, GRADO 60 | 28d | 2024-06-26 | 2024-07-30 | A1930 | 64d | 0d |
| A1950 |  | ENCOFRADO Y DESENCOFRADO CARA VISTA, OCULTA Y TUBOS PVC - D=4"/6" | 18d | 2024-07-31 | 2024-08-21 | A1940 | 64d | 0d |
| A1960 |  | CONCRETO CLASE A (F'C=280 KG/CM2)- PREMEZCLADO-CIMENTACION | 8d | 2024-08-22 | 2024-08-31 | A1950 | 64d | 0d |
| A1980 |  | CONCRETO CLASE A (F'C=280 KG/CM2)- PREMEZCLADO-LOSA | 6d | 2024-09-02 | 2024-09-07 | A1960 | 64d | 0d |
| A1970 |  | CONCRETO CLASE A (F'C=280 KG/CM2)- PREMEZCLADO-MUROS | 5d | 2024-09-09 | 2024-09-13 | A1980 | 64d | 0d |
| A1982 |  | BARANDA METÁLICA TÍPICA H=0.50M | 2d | 2024-09-14 | 2024-09-16 | A1970 | 86d |  |
|  | 3 | **F4 - ARQUITECTURA** |  | 2024-09-14 | 2024-09-23 |  |  |  |
| A1985 |  | PINTURA BITUMINOSA | 8d | 2024-09-14 | 2024-09-23 | A1970 | 80d | 0d |

| ID | WBS | Activity | Duration | Start | Finish | Predecessors | Total float | Free float |
| --- | --- | --- | --- | --- | --- | --- | --- | --- |
|  | 5 | **FRENTE 5 - INTERFERENCIAS** |  | 2024-06-24 | 2024-11-22 |  |  |  |
|  | 1 | **F5 - INTERFERENCIAS TIPO TUBERÍA** |  | 2024-06-24 | 2024-08-17 |  |  |  |
|  | 1 | **MOVIMIENTO DE TIERRAS** |  | 2024-06-24 | 2024-08-17 |  |  |  |
| A1993 |  | EXCAVACIONES PARA ESTRUCTURAS Y ZANJAS; NIVELACIÓN INTERIOR Y APISONADO C/EQ | 3d | 2024-06-24 | 2024-06-26 | A1740, A1040 SS | 20d | 0d |
| A1994 |  | RELLENO ESTRUCTURAL COMPACTADO | 4d | 2024-08-14 | 2024-08-17 | A2000 FS+14d | 110d |  |
|  | 2 | **OBRAS DE CONCRETO SIMPLE** |  | 2024-06-27 | 2024-06-27 |  |  |  |
| A1995 |  | CONCRETO CLASE F(F'C=100 KG/CM2) - SOLADOS | 1d | 2024-06-27 | 2024-06-27 | A1993 | 151d |  |
|  | 3 | **OBRAS DE CONCRETO ARMADO** |  | 2024-06-27 | 2024-07-26 |  |  |  |
| A1997 |  | ACERO FY=4200 KG/CM2, GRADO 60, CABLES, PERNOS Y GRAPAS | 11d | 2024-06-27 | 2024-07-10 | A1993 | 110d | 0d |
| A1998 |  | ENCOFRADO Y DESENCOFRADO CARA VISTA Y OCULTA | 12d | 2024-07-11 | 2024-07-24 | A1997 | 110d | 0d |
| A1996 |  | CONCRETO CLASE A (F'C=280 KG/CM2)- PREMEZCLADO-LOSA DE CIMENTACIÓN | 2d | 2024-07-25 | 2024-07-26 | A1998 | 110d | 0d |
| A2000 |  | CONCRETO CLASE A (F'C=280 KG/CM2)- PREMEZCLADO-MUROS | 1d | 2024-07-25 | 2024-07-25 | A1998 | 110d | 0d |
|  | 4 | **CARPINTERIA METÁLICA** |  | 2024-07-27 | 2024-07-27 |  |  |  |
| A2010 |  | SOPORTE METÁLICO TIPO L | 1d | 2024-07-27 | 2024-07-27 | A2000, A1996 | 110d | 0d |
|  | 5 | **INSTALACIONES HIDRÁULICAS** |  | 2024-07-30 | 2024-08-01 |  |  |  |
| A2020 |  | INSTALACIÓN HIDRÁULICA TUBERÍAS HDPE, UNIONES ACERROJADAS, COMPUERTA TIPO TARJETA 0.30X0.30, VÁLVULA, WATERSTOP 4" | 3d | 2024-07-30 | 2024-08-01 | A2010 | 110d | 0d |
|  | 6 | **ARQUITECTURA** |  | 2024-08-02 | 2024-08-10 |  |  |  |
| A2030 |  | PINTURA BITUMINOSA | 7d | 2024-08-02 | 2024-08-10 | A2020 | 116d |  |
|  | 2 | **F5 - INTERFERENCIAS TIPO DUCTO** |  | 2024-08-02 | 2024-08-17 |  |  |  |
|  | 1 | **MOVIMIENTO DE TIERRAS** |  | 2024-08-02 | 2024-08-13 |  |  |  |
| A2070 |  | EXCAVACIONES NO CLASIFICADAS PARA ESTRUCTURAS Y ZANJAS; NIVELACION INTERIOR Y APISONADO C/EQ | 1d | 2024-08-02 | 2024-08-02 | A2020 | 110d | 0d |
| A2090 |  | ACARREO DE MATERIAL EXCEDENTE HASTA UNA DISTANCIA PROMEDIO DE 30.0M | 1d | 2024-08-03 | 2024-08-03 | A2070 | 121d |  |
| A2080 |  | RELLENO ESTRUCTURAL COMPACTADO | 1d | 2024-08-13 | 2024-08-13 | A2130 | 114d |  |
|  | 2 | **OBRAS DE CONCRETO SIMPLE** |  | 2024-08-03 | 2024-08-03 |  |  |  |
| A2100 |  | CONCRETO CLASE F(F'C=100 KG/CM2) - SOLADOS Y EMBOQUILLADO DE PIEDRA F'C=175KG/CM2 e=0.30m | 1d | 2024-08-03 | 2024-08-03 | A2070 | 110d | 0d |

| ID | WBS | Activity | Duration | Start | Finish | Predecessors | Total float | Free float |
| --- | --- | --- | --- | --- | --- | --- | --- | --- |
|  | 3 | **OBRAS DE CONCRETO ARMADO** |  | 2024-08-05 | 2024-08-13 |  |  |  |
| A2110 |  | ACERO FY=4200 KG/CM2, GRADO 60 | 3d | 2024-08-05 | 2024-08-08 | A2100 | 110d | 0d |
| A2120 |  | ENCOFRADO Y DESENCOFRADO CARA VISTA Y OCULTA | 2d | 2024-08-09 | 2024-08-10 | A2110 | 110d | 0d |
| A2130 |  | CONCRETO CLASE B (F'C=280 KG/CM2)- PREMEZCLADO-LOSA | 1d | 2024-08-12 | 2024-08-12 | A2120 | 110d | 0d |
| A2145 |  | TAPA DE CONCRETO PREFABRICADA E=0.15M (F'C=280 KG/CM2) 0.70Mx0.70M | 0d | 2024-08-13 | 2024-08-13 | A2130 | 115d |  |
|  | 4 | **INSTALACIONES HIDRÁULICAS** |  | 2024-08-13 | 2024-08-13 |  |  |  |
| A2150 |  | COMPUERTA PLANA TIPO TARJETA 0.50m*0.50m | 1d | 2024-08-13 | 2024-08-13 | A2130 | 110d | 0d |
|  | 5 | **ARQUITECTURA** |  | 2024-08-14 | 2024-08-17 |  |  |  |
| A2160 |  | PINTURA BITUMINOSA | 4d | 2024-08-14 | 2024-08-17 | A2150 | 110d |  |
|  | 3 | **F5 - INTERFERENCIAS TIPO SIFONES** |  | 2024-06-24 | 2024-08-31 |  |  |  |
|  | 1 | **MOVIMIENTO DE TIERRAS** |  | 2024-06-24 | 2024-08-22 |  |  |  |
| A2200 |  | EXCAVACION NO CLASIFICADA PARA ESTRUCTURAS EN TERRENO NORMAL | 7d | 2024-06-24 | 2024-07-02 | A1993 SS | 20d | 0d |
| A2210 |  | CAMA DE APOYO CON ARENA E=0.20m | 2d | 2024-07-03 | 2024-07-04 | A2200 | 20d | 0d |
| A2230 |  | ACARREO DE MATERIAL EXCEDENTE HASTA UNA DISTANCIA PROMEDIO DE 30.0M | 5d | 2024-07-03 | 2024-07-08 | A2200 | 143d |  |
| A2220 |  | RELLENO ESTRUCTURAL COMPACTADO | 10d | 2024-08-12 | 2024-08-22 | A2290 | 106d |  |
|  | 2 | **OBRAS DE CONCRETO SIMPLE** |  | 2024-07-03 | 2024-07-05 |  |  |  |
| A2240 |  | CONCRETO CLASE B (F'C=280 KG/CM2)- PREMEZCLADO-MUROS | 3d | 2024-07-03 | 2024-07-05 | A2200 | 145d |  |
|  | 3 | **OBRAS DE CONCRETO ARMADO** |  | 2024-07-03 | 2024-08-17 |  |  |  |
| A2260 |  | ACERO FY=4200 KG/CM2, GRADO 60 | 14d | 2024-07-03 | 2024-07-18 | A2200 | 106d | 0d |
| A2270 |  | ENCOFRADO Y DESENCOFRADO CARA VISTA Y OCULTA | 14d | 2024-07-19 | 2024-08-05 | A2260 | 106d | 0d |
| A2280 |  | CONCRETO CLASE A (F'C=280 KG/CM2)- PREMEZCLADO-LOSA | 3d | 2024-08-07 | 2024-08-09 | A2270 | 117d |  |
| A2290 |  | CONCRETO CLASE A (F'C=280 KG/CM2)- PREMEZCLADO-MUROS Y MUROS DE ANCLAJE | 4d | 2024-08-07 | 2024-08-10 | A2270 | 106d | 0d |
| A2295 |  | TAPA DE CONCRETO PREFABRICADA E=0.12M (F'C=280KG/CM2) LmXBm | 6d | 2024-08-12 | 2024-08-17 | A2290 | 110d |  |
|  | 4 | **CARPINTERIA METÁLICA** |  | 2024-08-12 | 2024-08-20 |  |  |  |
| A2300 |  | REJILLAS METALICAS CON PLATINAS 3/8" DE VARIABLEXVARIABLE | 2d | 2024-08-12 | 2024-08-13 | A2290 | 108d | 0d |
| A2305 |  | ELEMENTOS METÁLICOS | 6d | 2024-08-14 | 2024-08-20 | A2300 | 108d |  |

| ID | WBS | Activity | Duration | Start | Finish | Predecessors | Total float | Free float |
| --- | --- | --- | --- | --- | --- | --- | --- | --- |
|  | 5 | **INSTALACIONES HIDRÁULICAS** |  | 2024-07-05 | 2024-08-21 |  |  |  |
| A2310 |  | TUBERIA HDPE NTP ISO 4427 PE-100 SDR 21 DNVARIABLE CON ACCESORIOS | 23d | 2024-07-05 | 2024-08-01 | A2210 | 20d | 0d |
| A2312 |  | COMPUERTA DESLIZANTE 0.5x0.4 | 2d | 2024-08-02 | 2024-08-03 | A2310 | 121d |  |
| A2315 |  | CAMARA DE CONCRETO TIPO A, d=1.20m, h, PROM (VARIABLE) Y COMPUERTA TIPO TARJETA VARIBLE | 16d | 2024-08-02 | 2024-08-21 | A2310 | 20d | 0d |
|  | 6 | **ARQUITECTURA** |  | 2024-08-22 | 2024-08-31 |  |  |  |
| A2320 |  | PINTURA BITUMINOSA | 8d | 2024-08-22 | 2024-08-31 | A2315 | 99d |  |
|  | 4 | **F5 - CANALES** |  | 2024-08-22 | 2024-09-10 |  |  |  |
|  | 1 | **MOVIMIENTO DE TIERRAS** |  | 2024-08-22 | 2024-09-10 |  |  |  |
| A2360 |  | EXCAVACION NO CLASIFICADA PARA ZANJAS EN TERRENO NORMAL | 10d | 2024-08-22 | 2024-09-03 | A2315 | 20d | 0d |
| A2380 |  | ACARREO DE MATERIAL EXCEDENTE HASTA UNA DISTANCIA PROMEDIO DE 30.0M | 2d | 2024-09-04 | 2024-09-05 | A2360 | 95d |  |
| A2370 |  | RELLENO ESTRUCTURAL COMPACTADO | 2d | 2024-09-09 | 2024-09-10 | A2390 | 91d |  |
|  | 2 | **OBRAS DE CONCRETO SIMPLE** |  | 2024-09-04 | 2024-09-07 |  |  |  |
| A2390 |  | ENCOFRADO Y DESENCOFRADO EN ESTRUCTURAS Y EMBOQUILLADO DE PIEDRA F'C=175KG/CM2 e=0.20m | 4d | 2024-09-04 | 2024-09-07 | A2360 | 20d | 0d |
|  | 3 | **INSTALACIONES HIDRÁULICAS** |  | 2024-09-09 | 2024-09-10 |  |  |  |
| A2440 |  | JUNTA WATERSTOP E=4" | 2d | 2024-09-09 | 2024-09-10 | A2390 | 91d |  |
|  | 5 | **F5 - ALCANTARILLAS Y BUZONES** |  | 2024-09-09 | 2024-11-22 |  |  |  |
|  | 1 | **MOVIMIENTO DE TIERRAS** |  | 2024-09-09 | 2024-11-13 |  |  |  |
| A2500 |  | EXCAVACION NO CLASIFICADA PARA ESTRUCTURAS EN TERRENO NORMAL | 4d | 2024-09-09 | 2024-09-12 | A2390 | 30d | 0d |
| A2510 |  | CAMA DE APOYO CON ARENA E=0.10m | 0d | 2024-09-13 | 2024-09-13 | A2500 | 89d |  |
| A2530 |  | ACARREO DE MATERIAL EXCEDENTE HASTA UNA DISTANCIA PROMEDIO DE 30.0M | 2d | 2024-09-13 | 2024-09-14 | A2500 | 87d |  |
| A2520 |  | RELLENO ESTRUCTURAL COMPACTADO | 2d | 2024-11-12 | 2024-11-13 | A2580 | 38d |  |
|  | 2 | **OBRAS DE CONCRETO SIMPLE** |  | 2024-09-13 | 2024-09-16 |  |  |  |
| A2540 |  | CONCRETO CLASE F(F'C=100 KG/CM2) - SOLADOS | 2d | 2024-09-13 | 2024-09-14 | A2500 | 30d | 0d |
| A2545 |  | ENCOFRADO Y DESENCOFRADO EN ESTRUCTURAS Y EMBOQUILLADO DE PIEDRA F'C=175KG/CM2 e=0.20m | 1d | 2024-09-16 | 2024-09-16 | A2540 | 86d |  |

| ID | WBS | Activity | Duration | Start | Finish | Predecessors | Total float | Free float |
| --- | --- | --- | --- | --- | --- | --- | --- | --- |
|  | 3 | **OBRAS DE CONCRETO ARMADO** |  | 2024-09-16 | 2024-11-11 |  |  |  |
| A2550 |  | ACERO FY=4200 KG/CM2, GRADO 60 | 28d | 2024-09-16 | 2024-10-18 | A2540 | 30d | 0d |
| A2560 |  | ENCOFRADO Y DESENCOFRADO CARA VISTA | 15d | 2024-10-19 | 2024-11-06 | A2550 | 30d | 0d |
| A2570 |  | CONCRETO CLASE B (F'C=280 KG/CM2)- PREMEZCLADO-LOSA | 3d | 2024-11-07 | 2024-11-09 | A2560, A2560 FF | 41d | 0d |
| A2580 |  | CONCRETO CLASE B (F'C=280 KG/CM2)- PREMEZCLADO-MUROS | 4d | 2024-11-07 | 2024-11-11 | A2560 | 30d | 0d |
|  | 4 | **CARPINTERIA METÁLICA** |  | 2024-11-11 | 2024-11-11 |  |  |  |
| A2582 |  | MARCO Y TAPA DE HD CON DOBLE PESTILLO Ø600mm | 0d | 2024-11-11 | 2024-11-11 | A2570 | 41d | 0d |
| A2584 |  | ESCALERA DE GATO Y SOPORTES P/ARNÉS DE SEGURIDAD | 0d | 2024-11-11 | 2024-11-11 | A2582 SS | 41d |  |
|  | 5 | **INSTALACIONES HIDRÁULICAS** |  | 2024-11-07 | 2024-11-08 |  |  |  |
| A2590 |  | INSTALACIONES HIDRÁULICAS | 2d | 2024-11-07 | 2024-11-08 | A2560 | 42d |  |
|  | 6 | **ARQUITECTURA** |  | 2024-11-12 | 2024-11-22 |  |  |  |
| A2600 |  | PINTURA BITUMINOSA | 10d | 2024-11-12 | 2024-11-22 | A2580 | 30d | 0d |
|  | 6 | **F5 - BADENES** |  | 2024-09-09 | 2024-10-02 |  |  |  |
|  | 1 | **MOVIMIENTO DE TIERRAS** |  | 2024-09-09 | 2024-09-16 |  |  |  |
| A2630 |  | Nivelacion interior y apisonado con equipo | 7d | 2024-09-09 | 2024-09-16 | A2390 | 20d | 0d |
|  | 2 | **OBRAS DE CONCRETO SIMPLE** |  | 2024-09-17 | 2024-09-17 |  |  |  |
| A2635 |  | Concreto Clase E (f'c=100 kg/cm2) concreto de nivelación | 1d | 2024-09-17 | 2024-09-17 | A2630 | 20d | 0d |
|  | 3 | **OBRAS DE CONCRETO ARMADO** |  | 2024-09-18 | 2024-10-01 |  |  |  |
| A2640 |  | ACERO FY=4200 KG/CM2, GRADO 60 | 7d | 2024-09-18 | 2024-09-25 | A2635 | 20d | 0d |
| A2650 |  | ENCOFRADO Y DESENCOFRADO CARA OCULTA | 4d | 2024-09-26 | 2024-09-30 | A2640 | 20d | 0d |
| A2660 |  | CONCRETO CLASE A (F'C=280 KG/CM2)- PREMEZCLADO-LOSA | 1d | 2024-10-01 | 2024-10-01 | A2650 | 20d | 0d |
|  | 4 | **INSTALACIONES HIDRÁULIAS** |  | 2024-10-02 | 2024-10-02 |  |  |  |
| A2680 |  | JUNTA DE DILATACIÓN | 1d | 2024-10-02 | 2024-10-02 | A2660 | 20d | 0d |
|  | 6 | **FRENTE 6 - INFRAESTRUCTURA VERDE Y PAISAJISMO** |  | 2024-10-03 | 2024-12-04 |  |  |  |
|  | 1 | **PREPARACIÓN DEL TERRENO** |  | 2024-10-03 | 2024-11-22 |  |  |  |
| A2730 |  | UBICACIÓN Y DELIMITACIÓN DE LA ZONA DE TRABAJO; TRAZADO, MARCACIÓN Y ESTACADO | 16d | 2024-10-03 | 2024-10-22 | A2680 | 20d | 0d |
| A2740 |  | PREPARACIÓN Y APORTE DEL SUSTRATO | 26d | 2024-10-23 | 2024-11-22 | A2730 | 20d | 0d |

| ID | WBS | Activity | Duration | Start | Finish | Predecessors | Total float | Free float |
| --- | --- | --- | --- | --- | --- | --- | --- | --- |
|  | 2 | **ESPECIES ARBÓREAS** |  | 2024-11-23 | 2024-11-26 |  |  |  |
| A2770 |  | SIEMBRA Y TRANSPORTE DE SCHINUS MOLLE (MOLLE) Y ACACIA MACRACANTHA (HUARANGO) | 3d | 2024-11-23 | 2024-11-26 | A2740 | 27d |  |
|  | 3 | **ESPECIES ARBUSTIVAS** |  | 2024-11-23 | 2024-12-04 |  |  |  |
| A2800 |  | SIEMBRA Y TRANSPORTE DE GALVEZIA FRUTICOSA (GALVEZIA) Y BOUGAINVILLEA PERUVIANA (BUGANVILLA) | 10d | 2024-11-23 | 2024-12-04 | A2740 | 20d |  |
|  | 4 | **MOBILIARIO URBANO** |  | 2024-10-23 | 2024-10-23 |  |  |  |
| A2820 |  | PAPELERA DE MADERA (75 LITROS) Y PIEDRA ORNAMENTAL DE GRANDES DIMENSIONES | 0d | 2024-10-23 | 2024-10-23 | A2730 | 56d |  |
|  | 5 | **SEÑALÉTICA INFORMATIVA** |  | 2024-10-23 | 2024-10-23 |  |  |  |
| A2830 |  | PANEL INFORMATIVO H=2.10 m TIPO B | 0d | 2024-10-23 | 2024-10-23 | A2730 | 56d |  |
|  | 6 | **ELEMENTOS ARQUITECTÓNICOS** |  | 2024-10-23 | 2024-10-25 |  |  |  |
| A2835 |  | BARANDA RÚSTICA DE MADERA DE HUAYRURO DE ALTURA H=1.00 M EN TERRENO / NATURAL | 3d | 2024-10-23 | 2024-10-25 | A2730 | 53d |  |
|  | 7 | **FRENTE 7 - MUROS DE CONTENCIÓN** |  | 2024-06-24 | 2024-07-13 |  |  |  |
|  | 1 | **F7 - OBRAS DE CONCRETO SIMPLE** |  | 2024-06-24 | 2024-06-24 |  |  |  |
| A2890 |  | CONCRETO CLASE F(F'C=100 KG/CM2) - SOLADOS | 1d | 2024-06-24 | 2024-06-24 | A1740 | 138d | 0d |
|  | 2 | **F7 - OBRAS DE CONCRETO ARMADO** |  | 2024-06-25 | 2024-07-11 |  |  |  |
| A2900 |  | ACERO FY=4200 KG/CM2, GRADO 60 | 6d | 2024-06-25 | 2024-07-02 | A2890 | 138d | 0d |
| A2910 |  | ENCOFRADO Y DESENCOFRADO CARA OCULTA | 5d | 2024-07-03 | 2024-07-08 | A2900 | 138d | 0d |
| A2920 |  | CONCRETO CLASE A (F'C=280 KG/CM2)- PREMEZCLADO-CIMENTACION | 1d | 2024-07-09 | 2024-07-09 | A2910 | 138d | 0d |
| A2930 |  | CONCRETO CLASE A (F'C=280 KG/CM2)- PREMEZCLADO-MUROS | 1d | 2024-07-10 | 2024-07-10 | A2920 | 138d | 0d |
| A2932 |  | BARRERA DE SEGURIDAD RIGIDA TIPO NEW JERSEY PREFABRICADA | 1d | 2024-07-11 | 2024-07-11 | A2930 | 140d |  |
|  | 3 | **F7 - ARQUITECTURA** |  | 2024-07-11 | 2024-07-13 |  |  |  |
| A2935 |  | PINTURA BITUMINOSA | 3d | 2024-07-11 | 2024-07-13 | A2930 | 138d |  |
|  | 8 | **FRENTE 8 - PAVIMENTO RÍGIDO** |  | 2024-09-14 | 2024-10-12 |  |  |  |
| A2940 |  | ACERO FY=4200 KG/CM2, GRADO 60 | 13d | 2024-09-14 | 2024-09-28 | A1970 | 64d | 0d |
| A2950 |  | ENCOFRADO Y DESENCOFRADO DE PAVIMENTOS | 3d | 2024-09-30 | 2024-10-02 | A2940 | 64d | 0d |
| A2960 |  | PAVIMENTO HIDRAULICO (F'C 300KG/CM2) | 6d | 2024-10-03 | 2024-10-10 | A2950 | 64d | 0d |
| A2970 |  | JUNTA TRANSVERSAL DE CONTRACCIÓN | 2d | 2024-10-11 | 2024-10-12 | A2960 | 64d |  |

| ID | WBS | Activity | Duration | Start | Finish | Predecessors | Total float | Free float |
| --- | --- | --- | --- | --- | --- | --- | --- | --- |
|  | 2 | **ETAPA II - JACAYITA Y PICAMARÁN** |  | 2024-08-14 | 2024-12-23 |  |  |  |
|  | 1 | **FRENTE 1 - DEMOLICIONES** |  | 2024-08-14 | 2024-08-19 |  |  |  |
| A3710 |  | Demolicion de Canales en Qdas. y Badenes | 0d | 2024-08-14 | 2024-08-14 | A1090 SS | 0d |  |
| A3720 |  | Demolicion de Pavimentos, veredas y cerco perimétrico | 3d | 2024-08-14 | 2024-08-16 | A3710 | 109d | 0d |
| A3725 |  | Eliminacion de material de demolicion | 2d | 2024-08-17 | 2024-08-19 | A3720 | 109d |  |
|  | 2 | **FRENTE 2 - MOVIMIENTO DE TIERRAS** |  | 2024-08-14 | 2024-12-03 |  |  |  |
| A3730 |  | Desbroce | 3d | 2024-08-14 | 2024-08-16 | A3710 | 0d |  |
| A3740 |  | Excavación de cimentación | 37d | 2024-08-17 | 2024-09-30 | A3730 | 0d |  |
| A3820 |  | Suministro de Roca | 49d | 2024-08-20 | 2024-10-17 | A3780 FF | 60d |  |
| A3750 |  | Perfilado y conformación de Plataforma de fundación | 20d | 2024-09-07 | 2024-09-30 | A3740 FF | 0d |  |
| A3760 |  | Conformación de material excedente en DME y DMO | 24d | 2024-10-01 | 2024-10-29 | A3740 | 50d |  |
| A3770 |  | Relleno con material granular (incluye extracción de material, zarandeo y combinación de material) | 2d | 2024-10-01 | 2024-10-02 | A3750 | 72d |  |
| A3780 |  | Relleno Estructural | 14d | 2024-10-01 | 2024-10-17 | A3750 | 21d | 0d |
| A3830 |  | Roca Recebada | 37d | 2024-10-18 | 2024-11-30 | A3780 | 21d | 0d |
| A3825 |  | Colocación de Roca en Uña | 20d | 2024-11-08 | 2024-11-30 | A3830 FF | 23d |  |
| A3840 |  | Subbase granular | 2d | 2024-12-02 | 2024-12-03 | A3830 | 21d |  |
|  | 3 | **FRENTE 3 - ESTRUCTURAS CANALIZADAS** |  | 2024-08-20 | 2024-12-19 |  |  |  |
|  | 1 | **F3 - OBRAS DE CONCRETO SIMPLE** |  | 2024-08-20 | 2024-10-09 |  |  |  |
| A3845 |  | ENCOFRADO Y DESENCOFRADO CARA OCULTA | 22d | 2024-08-20 | 2024-09-14 | A3740 SS+2d | 67d | 0d |
| A3850 |  | CONCRETO CLASE F(F'C=100 KG/CM2) - SOLADOS | 11d | 2024-09-16 | 2024-09-27 | A3845 | 67d | 0d |
| A3860 |  | CONCRETO CLASE A (F'C=280 KG/CM2)- PREMEZCLADO-MUROS+30% PM / DMAX=4"/6" | 9d | 2024-09-28 | 2024-10-09 | A3850 | 67d |  |
|  | 2 | **F3 - OBRAS DE CONCRETO ARMADO** |  | 2024-09-19 | 2024-12-19 |  |  |  |
| A3870 |  | GEOCOMPUESTO DE DRENAJE | 4d | 2024-09-19 | 2024-09-23 | A3750 SS+10d | 8d | 0d |
| A3880 |  | ACERO FY=4200 KG/CM2, GRADO 60 | 45d | 2024-09-24 | 2024-11-16 | A3870 | 8d | 0d |
| A3890 |  | ENCOFRADO Y DESENCOFRADO CARA VISTA, OCULTA Y TUBOS PVC - D=4"/6" | 23d | 2024-11-18 | 2024-12-14 | A3880 | 8d | 0d |
| A3900 |  | CONCRETO CLASE A (F'C=280 KG/CM2)- PREMEZCLADO-MUROS+30% PM DMAX=6" | 4d | 2024-12-16 | 2024-12-19 | A3890 | 8d | 0d |

| ID | WBS | Activity | Duration | Start | Finish | Predecessors | Total float | Free float |
| --- | --- | --- | --- | --- | --- | --- | --- | --- |
|  | 4 | **FRENTE 4 - PASO SUPERIOR TIPO MARCO** |  | 2024-10-01 | 2024-12-14 |  |  |  |
|  | 1 | **F4 - OBRAS DE CONCRETO SIMPLE** |  | 2024-10-01 | 2024-10-04 |  |  |  |
| A3920 |  | ENCOFRADO Y DESENCOFRADO EN ESTRUCTURAS | 2d | 2024-10-01 | 2024-10-02 | A4840 SS | 70d | 0d |
| A3910 |  | CONCRETO CLASE F(F'C=100 KG/CM2) - SOLADOS | 2d | 2024-10-03 | 2024-10-04 | A3920 | 70d |  |
|  | 2 | **F4 - OBRAS DE CONCRETO ARMADO** |  | 2024-10-01 | 2024-12-04 |  |  |  |
| A3930 |  | GEOCOMPUESTO DE DRENAJE | 2d | 2024-10-01 | 2024-10-02 | A3750 | 0d |  |
| A3940 |  | ACERO FY=4200 KG/CM2, GRADO 60 | 19d | 2024-10-03 | 2024-10-25 | A3930 | 0d |  |
| A3950 |  | ENCOFRADO Y DESENCOFRADO CARA VISTA, OCULTA Y TUBOS PVC - D=4"/6" | 17d | 2024-10-26 | 2024-11-15 | A3940 | 0d |  |
| A3960 |  | CONCRETO CLASE A (F'C=280 KG/CM2)- PREMEZCLADO-CIMENTACION | 6d | 2024-11-16 | 2024-11-22 | A3950 | 0d |  |
| A3980 |  | CONCRETO CLASE A (F'C=280 KG/CM2)- PREMEZCLADO-LOSA | 4d | 2024-11-23 | 2024-11-27 | A3960 | 0d |  |
| A3970 |  | CONCRETO CLASE A (F'C=280 KG/CM2)- PREMEZCLADO-MUROS | 4d | 2024-11-28 | 2024-12-02 | A3980 | 0d |  |
| A3982 |  | BARANDA METÁLICA TÍPICA H=0.50M | 2d | 2024-12-03 | 2024-12-04 | A3970 | 20d |  |
|  | 3 | **F4 - ARQUITECTURA** |  | 2024-12-03 | 2024-12-14 |  |  |  |
| A3985 |  | PINTURA BITUMINOSA | 10d | 2024-12-03 | 2024-12-14 | A3970 | 12d | 0d |
|  | 5 | **FRENTE 5 - INTERFERENCIAS** |  | 2024-10-01 | 2024-12-04 |  |  |  |
|  | 1 | **F5 - INTERFERENCIAS TIPO TUBERÍA** |  | 2024-10-01 | 2024-12-02 |  |  |  |
|  | 1 | **MOVIMIENTO DE TIERRAS** |  | 2024-10-01 | 2024-11-23 |  |  |  |
| A3993 |  | EXCAVACIONES PARA ESTRUCTURAS Y ZANJAS; NIVELACIÓN INTERIOR Y APISONADO C/EQ | 2d | 2024-10-01 | 2024-10-02 | A4850 SS | 22d | 0d |
| A3994 |  | RELLENO ESTRUCTURAL COMPACTADO | 1d | 2024-11-23 | 2024-11-23 | A4000 | 29d |  |
|  | 2 | **OBRAS DE CONCRETO SIMPLE** |  | 2024-10-03 | 2024-10-03 |  |  |  |
| A3995 |  | CONCRETO CLASE F(F'C=100 KG/CM2) - SOLADOS | 1d | 2024-10-03 | 2024-10-03 | A3993 | 22d | 0d |
|  | 3 | **OBRAS DE CONCRETO ARMADO** |  | 2024-10-04 | 2024-11-22 |  |  |  |
| A3997 |  | ACERO FY=4200 KG/CM2, GRADO 60, CABLES, PERNOS Y GRAPAS | 13d | 2024-10-04 | 2024-10-19 | A3995 | 22d | 0d |
| A3998 |  | ENCOFRADO Y DESENCOFRADO CARA VISTA Y OCULTA | 24d | 2024-10-21 | 2024-11-18 | A3997 | 22d | 0d |
| A3996 |  | CONCRETO CLASE A (F'C=280 KG/CM2)- PREMEZCLADO-LOSA DE CIMENTACIÓN | 2d | 2024-11-19 | 2024-11-20 | A3998 | 22d | 0d |
| A4000 |  | CONCRETO CLASE A (F'C=280 KG/CM2)- PREMEZCLADO-MUROS | 2d | 2024-11-21 | 2024-11-22 | A3996 | 22d | 0d |

| ID | WBS | Activity | Duration | Start | Finish | Predecessors | Total float | Free float |
| --- | --- | --- | --- | --- | --- | --- | --- | --- |
|  | 4 | **CARPINTERIA METÁLICA** |  | 2024-11-23 | 2024-11-23 |  |  |  |
| A4010 |  | SOPORTE METÁLICO TIPO L | 0d | 2024-11-23 | 2024-11-23 | A4000 | 30d |  |
|  | 5 | **INSTALACIONES HIDRÁULICAS** |  | 2024-11-23 | 2024-11-26 |  |  |  |
| A4020 |  | INSTALACIÓN HIDRÁULICA TUBERÍAS HDPE, UNIONES ACERROJADAS, COMPUERTA TIPO TARJETA 0.30X0.30, VÁLVULA, WATERSTOP 4" | 3d | 2024-11-23 | 2024-11-26 | A4000 | 27d |  |
|  | 6 | **ARQUITECTURA** |  | 2024-11-23 | 2024-12-02 |  |  |  |
| A4030 |  | PINTURA BITUMINOSA | 8d | 2024-11-23 | 2024-12-02 | A4000 | 22d |  |
|  | 2 | **F5 - INTERFERENCIAS TIPO DUCTO** |  | 2024-10-01 | 2024-10-19 |  |  |  |
|  | 1 | **MOVIMIENTO DE TIERRAS** |  | 2024-10-01 | 2024-10-15 |  |  |  |
| A4070 |  | EXCAVACIONES NO CLASIFICADAS PARA ESTRUCTURAS Y ZANJAS; NIVELACION INTERIOR Y APISONADO C/EQ | 2d | 2024-10-01 | 2024-10-02 | A4850 SS | 40d | 0d |
| A4090 |  | ACARREO DE MATERIAL EXCEDENTE HASTA UNA DISTANCIA PROMEDIO DE 30.0M | 1d | 2024-10-03 | 2024-10-03 | A4070 | 71d |  |
| A4080 |  | RELLENO ESTRUCTURAL COMPACTADO | 1d | 2024-10-15 | 2024-10-15 | A4130 | 62d |  |
|  | 2 | **OBRAS DE CONCRETO SIMPLE** |  | 2024-10-03 | 2024-10-03 |  |  |  |
| A4100 |  | CONCRETO CLASE F(F'C=100 KG/CM2) - SOLADOS Y EMBOQUILLADO DE PIEDRA F'C=175KG/CM2 e=0.30m | 1d | 2024-10-03 | 2024-10-03 | A4070 | 40d | 0d |
|  | 3 | **OBRAS DE CONCRETO ARMADO** |  | 2024-10-04 | 2024-10-17 |  |  |  |
| A4110 |  | ACERO FY=4200 KG/CM2, GRADO 60 | 4d | 2024-10-04 | 2024-10-09 | A4100 | 40d | 0d |
| A4120 |  | ENCOFRADO Y DESENCOFRADO CARA VISTA Y OCULTA | 3d | 2024-10-10 | 2024-10-12 | A4110 | 40d | 0d |
| A4130 |  | CONCRETO CLASE B (F'C=280 KG/CM2)- PREMEZCLADO-LOSA | 1d | 2024-10-14 | 2024-10-14 | A4120 | 40d | 0d |
| A4145 |  | TAPA DE CONCRETO PREFABRICADA E=0.15M (F'C=280 KG/CM2) 0.70Mx0.70M | 3d | 2024-10-15 | 2024-10-17 | A4130 | 60d |  |
|  | 4 | **INSTALACIONES HIDRÁULICAS** |  | 2024-10-15 | 2024-10-16 |  |  |  |
| A4150 |  | COMPUERTA PLANA TIPO TARJETA 0.50m*0.50m | 2d | 2024-10-15 | 2024-10-16 | A4130 | 61d |  |
|  | 5 | **ARQUITECTURA** |  | 2024-10-15 | 2024-10-19 |  |  |  |
| A4160 |  | PINTURA BITUMINOSA | 5d | 2024-10-15 | 2024-10-19 | A4130 | 58d |  |
|  | 3 | **F5 - INTERFERENCIAS TIPO SIFONES** |  | 2024-10-15 | 2024-11-11 |  |  |  |
|  | 1 | **MOVIMIENTO DE TIERRAS** |  | 2024-10-15 | 2024-11-07 |  |  |  |
| A4200 |  | EXCAVACION NO CLASIFICADA PARA ESTRUCTURAS EN TERRENO NORMAL | 5d | 2024-10-15 | 2024-10-19 | A4130 | 40d | 0d |
| A4210 |  | CAMA DE APOYO CON ARENA E=0.20m | 2d | 2024-10-21 | 2024-10-22 | A4200 | 47d | 0d |
| A4230 |  | ACARREO DE MATERIAL EXCEDENTE HASTA UNA DISTANCIA PROMEDIO DE 30.0M | 2d | 2024-10-21 | 2024-10-22 | A4200 | 56d |  |
| A4220 |  | RELLENO ESTRUCTURAL COMPACTADO | 3d | 2024-11-05 | 2024-11-07 | A4290 | 43d |  |

| ID | WBS | Activity | Duration | Start | Finish | Predecessors | Total float | Free float |
| --- | --- | --- | --- | --- | --- | --- | --- | --- |
|  | 2 | **OBRAS DE CONCRETO SIMPLE** |  | 2024-10-21 | 2024-10-23 |  |  |  |
| A4240 |  | CONCRETO CLASE B (F'C=280 KG/CM2)- PREMEZCLADO-MUROS | 3d | 2024-10-21 | 2024-10-23 | A4200 | 55d |  |
|  | 3 | **OBRAS DE CONCRETO ARMADO** |  | 2024-10-21 | 2024-11-05 |  |  |  |
| A4260 |  | ACERO FY=4200 KG/CM2, GRADO 60 | 4d | 2024-10-21 | 2024-10-24 | A4200 | 40d | 0d |
| A4270 |  | ENCOFRADO Y DESENCOFRADO CARA VISTA Y OCULTA | 4d | 2024-10-25 | 2024-10-29 | A4260 | 40d | 0d |
| A4280 |  | CONCRETO CLASE A (F'C=280 KG/CM2)- PREMEZCLADO-LOSA | 2d | 2024-10-30 | 2024-10-31 | A4270 | 40d | 0d |
| A4290 |  | CONCRETO CLASE A (F'C=280 KG/CM2)- PREMEZCLADO-MUROS Y MUROS DE ANCLAJE | 2d | 2024-11-02 | 2024-11-04 | A4280 | 40d | 0d |
| A4295 |  | TAPA DE CONCRETO PREFABRICADA E=0.12M (F'C=280KG/CM2) LmXBm | 1d | 2024-11-05 | 2024-11-05 | A4290 | 45d |  |
|  | 4 | **CARPINTERIA METÁLICA** |  | 2024-11-05 | 2024-11-11 |  |  |  |
| A4300 |  | REJILLAS METALICAS CON PLATINAS 3/8" DE VARIABLEXVARIABLE | 2d | 2024-11-05 | 2024-11-06 | A4290 | 40d | 0d |
| A4305 |  | ELEMENTOS METÁLICOS | 6d | 2024-11-05 | 2024-11-11 | A4300 SS | 40d |  |
|  | 5 | **INSTALACIONES HIDRÁULICAS** |  | 2024-10-23 | 2024-11-08 |  |  |  |
| A4310 |  | TUBERIA HDPE NTP ISO 4427 PE-100 SDR 21 DNVARIABLE CON ACCESORIOS | 9d | 2024-10-23 | 2024-11-02 | A4210 | 47d |  |
| A4312 |  | COMPUERTA DESLIZANTE 0.5x0.4 | 2d | 2024-11-05 | 2024-11-06 | A4290 | 44d |  |
| A4315 |  | CAMARA DE CONCRETO TIPO A, d=1.20m, h, PROM (VARIABLE) Y COMPUERTA TIPO TARJETA VARIBLE | 4d | 2024-11-05 | 2024-11-08 | A4290 | 42d |  |
|  | 6 | **ARQUITECTURA** |  | 2024-11-05 | 2024-11-06 |  |  |  |
| A4320 |  | PINTURA BITUMINOSA | 2d | 2024-11-05 | 2024-11-06 | A4290 | 44d |  |
|  | 4 | **F5 - CANALES** |  | 2024-10-01 | 2024-10-19 |  |  |  |
|  | 1 | **MOVIMIENTO DE TIERRAS** |  | 2024-10-01 | 2024-10-19 |  |  |  |
| A4360 |  | EXCAVACION NO CLASIFICADA PARA ZANJAS EN TERRENO NORMAL | 11d | 2024-10-01 | 2024-10-14 | A4850 SS | 58d | 0d |
| A4380 |  | ACARREO DE MATERIAL EXCEDENTE HASTA UNA DISTANCIA PROMEDIO DE 30.0M | 3d | 2024-10-15 | 2024-10-17 | A4360 | 60d |  |
| A4370 |  | RELLENO ESTRUCTURAL COMPACTADO | 2d | 2024-10-18 | 2024-10-19 | A4390 | 58d |  |
|  | 2 | **OBRAS DE CONCRETO SIMPLE** |  | 2024-10-15 | 2024-10-17 |  |  |  |
| A4390 |  | ENCOFRADO Y DESENCOFRADO EN ESTRUCTURAS Y EMBOQUILLADO DE PIEDRA F'C=175KG/CM2 e=0.20m | 3d | 2024-10-15 | 2024-10-17 | A4360 | 58d | 0d |

| ID | WBS | Activity | Duration | Start | Finish | Predecessors | Total float | Free float |
| --- | --- | --- | --- | --- | --- | --- | --- | --- |
|  | 3 | **INSTALACIONES HIDRÁULICAS** |  | 2024-10-18 | 2024-10-18 |  |  |  |
| A4440 |  | JUNTA WATERSTOP E=4" | 1d | 2024-10-18 | 2024-10-18 | A4390 | 59d |  |
|  | 5 | **F5 - ALCANTARILLAS Y BUZONES** |  | 2024-10-01 | 2024-12-04 |  |  |  |
|  | 1 | **MOVIMIENTO DE TIERRAS** |  | 2024-10-01 | 2024-11-20 |  |  |  |
| A4500 |  | EXCAVACION NO CLASIFICADA PARA ESTRUCTURAS EN TERRENO NORMAL | 7d | 2024-10-01 | 2024-10-09 | A4850 SS | 20d | 0d |
| A4510 |  | CAMA DE APOYO CON ARENA E=0.10m | 2d | 2024-10-10 | 2024-10-11 | A4500 | 65d |  |
| A4530 |  | ACARREO DE MATERIAL EXCEDENTE HASTA UNA DISTANCIA PROMEDIO DE 30.0M | 4d | 2024-10-10 | 2024-10-14 | A4500 | 63d |  |
| A4520 |  | RELLENO ESTRUCTURAL COMPACTADO | 3d | 2024-11-18 | 2024-11-20 | A4570, A4580 | 32d |  |
|  | 2 | **OBRAS DE CONCRETO SIMPLE** |  | 2024-10-10 | 2024-10-14 |  |  |  |
| A4540 |  | CONCRETO CLASE F(F'C=100 KG/CM2) - SOLADOS | 2d | 2024-10-10 | 2024-10-11 | A4500 | 20d | 0d |
| A4545 |  | ENCOFRADO Y DESENCOFRADO EN ESTRUCTURAS Y EMBOQUILLADO DE PIEDRA F'C=175KG/CM2 e=0.20m | 2d | 2024-10-12 | 2024-10-14 | A4540 | 63d |  |
|  | 3 | **OBRAS DE CONCRETO ARMADO** |  | 2024-10-12 | 2024-11-16 |  |  |  |
| A4550 |  | ACERO FY=4200 KG/CM2, GRADO 60 | 13d | 2024-10-12 | 2024-10-26 | A4540 | 20d | 0d |
| A4560 |  | ENCOFRADO Y DESENCOFRADO CARA VISTA | 11d | 2024-10-28 | 2024-11-09 | A4550 | 20d | 0d |
| A4570 |  | CONCRETO CLASE B (F'C=280 KG/CM2)- PREMEZCLADO-LOSA | 2d | 2024-11-11 | 2024-11-12 | A4560 | 20d | 0d |
| A4580 |  | CONCRETO CLASE B (F'C=280 KG/CM2)- PREMEZCLADO-MUROS | 4d | 2024-11-13 | 2024-11-16 | A4570 | 20d | 0d |
|  | 4 | **CARPINTERIA METÁLICA** |  | 2024-11-18 | 2024-11-23 |  |  |  |
| A4582 |  | MARCO Y TAPA DE HD CON DOBLE PESTILLO Ø600mm | 6d | 2024-11-18 | 2024-11-23 | A4580 | 29d |  |
| A4584 |  | ESCALERA DE GATO Y SOPORTES P/ARNÉS DE SEGURIDAD | 6d | 2024-11-18 | 2024-11-23 | A4580 | 29d |  |
|  | 5 | **INSTALACIONES HIDRÁULICAS** |  | 2024-11-18 | 2024-12-04 |  |  |  |
| A4590 |  | INSTALACIONES HIDRÁULICAS | 15d | 2024-11-18 | 2024-12-04 | A4580 | 20d | 0d |
|  | 6 | **ARQUITECTURA** |  | 2024-11-18 | 2024-11-26 |  |  |  |
| A4600 |  | PINTURA BITUMINOSA | 8d | 2024-11-18 | 2024-11-26 | A4580 | 27d |  |
|  | 6 | **F5 - BADENES** |  | 2024-10-01 | 2024-10-01 |  |  |  |
|  | 1 | **MOVIMIENTO DE TIERRAS** |  | 2024-10-01 | 2024-10-01 |  |  |  |
| A4630 |  | Nivelacion interior y apisonado con equipo | 0d | 2024-10-01 | 2024-10-01 | A4850 SS | 19d | 0d |

| ID | WBS | Activity | Duration | Start | Finish | Predecessors | Total float | Free float |
| --- | --- | --- | --- | --- | --- | --- | --- | --- |
|  | 2 | **OBRAS DE CONCRETO SIMPLE** |  | 2024-10-01 | 2024-10-01 |  |  |  |
| A4635 |  | Concreto Clase E (f'c=100 kg/cm2) concreto de nivelación | 0d | 2024-10-01 | 2024-10-01 | A4630 | 19d | 0d |
|  | 3 | **OBRAS DE CONCRETO ARMADO** |  | 2024-10-01 | 2024-10-01 |  |  |  |
| A4640 |  | ACERO FY=4200 KG/CM2, GRADO 60 | 0d | 2024-10-01 | 2024-10-01 | A4635 | 19d | 0d |
| A4650 |  | ENCOFRADO Y DESENCOFRADO CARA OCULTA | 0d | 2024-10-01 | 2024-10-01 | A4640 | 19d | 0d |
| A4660 |  | CONCRETO CLASE A (F'C=280 KG/CM2)- PREMEZCLADO-LOSA | 0d | 2024-10-01 | 2024-10-01 | A4650 | 19d | 0d |
|  | 4 | **INSTALACIONES HIDRÁULIAS** |  | 2024-10-01 | 2024-10-01 |  |  |  |
| A4680 |  | JUNTA DE DILATACIÓN | 0d | 2024-10-01 | 2024-10-01 | A4660 | 74d |  |
|  | 6 | **FRENTE 6 - INFRAESTRUCTURA VERDE Y PAISAJISMO** |  | 2024-10-01 | 2024-12-05 |  |  |  |
|  | 1 | **PREPARACIÓN DEL TERRENO** |  | 2024-10-01 | 2024-11-13 |  |  |  |
| A4730 |  | UBICACIÓN Y DELIMITACIÓN DE LA ZONA DE TRABAJO; TRAZADO, MARCACIÓN Y ESTACADO | 13d | 2024-10-01 | 2024-10-16 | A4660 | 19d | 0d |
| A4740 |  | PREPARACIÓN Y APORTE DEL SUSTRATO | 23d | 2024-10-17 | 2024-11-13 | A4730 | 19d | 0d |
|  | 2 | **ESPECIES ARBÓREAS** |  | 2024-11-14 | 2024-11-16 |  |  |  |
| A4770 |  | SIEMBRA Y TRANSPORTE DE SCHINUS MOLLE (MOLLE) Y ACACIA MACRACANTHA (HUARANGO) | 3d | 2024-11-14 | 2024-11-16 | A4740 | 19d | 0d |
|  | 3 | **ESPECIES ARBUSTIVAS** |  | 2024-11-18 | 2024-11-28 |  |  |  |
| A4800 |  | SIEMBRA Y TRANSPORTE DE GALVEZIA FRUTICOSA (GALVEZIA) Y BOUGAINVILLEA PERUVIANA (BUGANVILLA) | 10d | 2024-11-18 | 2024-11-28 | A4770 | 19d | 0d |
|  | 4 | **MOBILIARIO URBANO** |  | 2024-11-29 | 2024-11-29 |  |  |  |
| A4820 |  | PAPELERA DE MADERA (75 LITROS) Y PIEDRA ORNAMENTAL DE GRANDES DIMENSIONES | 0d | 2024-11-29 | 2024-11-29 | A4800 | 25d |  |
|  | 5 | **SEÑALÉTICA INFORMATIVA** |  | 2024-11-29 | 2024-11-29 |  |  |  |
| A4830 |  | PANEL INFORMATIVO H=2.10 m TIPO B | 0d | 2024-11-29 | 2024-11-29 | A4800 | 25d |  |
|  | 6 | **ELEMENTOS ARQUITECTÓNICOS** |  | 2024-11-29 | 2024-12-05 |  |  |  |
| A4835 |  | BARANDA RÚSTICA DE MADERA DE HUAYRURO DE ALTURA H=1.00 M EN TERRENO / NATURAL | 6d | 2024-11-29 | 2024-12-05 | A4800 | 19d |  |
|  | 7 | **FRENTE 7 - MUROS DE CONTENCIÓN** |  | 2024-10-03 | 2024-10-03 |  |  |  |
|  | 1 | **F7 - OBRAS DE CONCRETO SIMPLE** |  | 2024-10-03 | 2024-10-03 |  |  |  |
| A4890 |  | CONCRETO CLASE F(F'C=100 KG/CM2) - SOLADOS | 0d | 2024-10-03 | 2024-10-03 | A3993 | 72d | 0d |

| ID | WBS | Activity | Duration | Start | Finish | Predecessors | Total float | Free float |
| --- | --- | --- | --- | --- | --- | --- | --- | --- |
|  | 2 | **F7 - OBRAS DE CONCRETO ARMADO** |  | 2024-10-03 | 2024-10-03 |  |  |  |
| A4900 |  | ACERO FY=4200 KG/CM2, GRADO 60 | 0d | 2024-10-03 | 2024-10-03 | A4890 | 72d | 0d |
| A4910 |  | ENCOFRADO Y DESENCOFRADO CARA OCULTA | 0d | 2024-10-03 | 2024-10-03 | A4900 | 72d | 0d |
| A4920 |  | CONCRETO CLASE A (F'C=280 KG/CM2)- PREMEZCLADO-CIMENTACION | 0d | 2024-10-03 | 2024-10-03 | A4910 | 72d | 0d |
| A4930 |  | CONCRETO CLASE A (F'C=280 KG/CM2)- PREMEZCLADO-MUROS | 0d | 2024-10-03 | 2024-10-03 | A4920 | 72d | 0d |
| A4932 |  | BARRERA DE SEGURIDAD RIGIDA TIPO NEW JERSEY PREFABRICADA | 0d | 2024-10-03 | 2024-10-03 | A4930 | 72d |  |
|  | 3 | **F7 - ARQUITECTURA** |  | 2024-10-03 | 2024-10-03 |  |  |  |
| A4935 |  | PINTURA BITUMINOSA | 0d | 2024-10-03 | 2024-10-03 | A4930 | 72d |  |
|  | 8 | **FRENTE 8 - PAVIMENTO RÍGIDO** |  | 2024-12-03 | 2024-12-23 |  |  |  |
| A4940 |  | ACERO FY=4200 KG/CM2, GRADO 60 | 9d | 2024-12-03 | 2024-12-13 | A3970 | 0d |  |
| A4950 |  | ENCOFRADO Y DESENCOFRADO DE PAVIMENTOS | 2d | 2024-12-14 | 2024-12-16 | A4940 | 0d |  |
| A4960 |  | PAVIMENTO HIDRAULICO (F'C 300KG/CM2) | 4d | 2024-12-17 | 2024-12-20 | A4950 | 0d |  |
| A4970 |  | JUNTA TRANSVERSAL DE CONTRACCIÓN | 2d | 2024-12-21 | 2024-12-23 | A4960 | 5d | 0d |
